# DLSCAP 2006 Work Plan

Schedule from MS Project, 2005-08-01 to 2005-09-01.
MBARI

## Calendars

- Standard: Mon-Fri 08:00-12:00, 13:00-17:00; Sat-Sun off.

## Resources

| Resource |
| --- |
| Lance |
| Brett |
| Thomas |
| Machine shop |
| Jon |
| Lance McBride |
| Thomas Hoover |
| Test Tank |
| Rob Mcewen |
| Zephyr |
| Brett Hobson |
| Jon Erickson |
| AUV Fabricator #1 |
| Mike Godin |
| Yanwu Zhang |
| Rich |
| EE |
| SE |
| ME |
| MS |
| RE |
| ET |
| MT |
| SE ME |

## Schedule

| ID | WBS | Task | Type | Duration | Start | Finish | Predecessors | Total slack | Free slack | Resources | Work |
| --- | --- | --- | --- | --- | --- | --- | --- | --- | --- | --- | --- |
| 1 | 1 | **DLSCAP 2006 Work Plan** |  | 24d? | 2005-08-01 | 2005-09-01 |  | 0d |  |  | 472h |
| 2 | 1.1 | **LP-VB system** |  | 19d? | 2005-08-01 | 2005-08-25 |  | 5d |  |  | 152h |
| 3 | 1.1.1 | **Mechanical design** |  | 9d? | 2005-08-01 | 2005-08-11 |  | 5d |  |  | 72h |
| 4 | 1.1.1.1 | layout |  | 5d? | 2005-08-01 | 2005-08-05 |  | 5d | 0d | ME | 40h |
| 5 | 1.1.1.2 | component spec |  | 1d? | 2005-08-08 | 2005-08-08 | 4 | 5d | 0d | ME | 8h |
| 6 | 1.1.1.3 | machine prints |  | 3d? | 2005-08-09 | 2005-08-11 | 5 | 5d | 0d | ME | 24h |
| 7 | 1.1.2 | machine parts |  | 3d? | 2005-08-12 | 2005-08-16 | 6 | 5d | 0d | MS | 24h |
| 8 | 1.1.3 | assemble and test |  | 1d? | 2005-08-17 | 2005-08-17 | 7 | 5d | 0d | ME | 8h |
| 9 | 1.1.4 | install and test in tank |  | 2d? | 2005-08-18 | 2005-08-19 | 8 | 5d | 0d | ME | 16h |
| 10 | 1.1.5 | rework |  | 1d? | 2005-08-22 | 2005-08-22 | 9 | 5d | 0d | ME | 8h |
| 11 | 1.1.6 | final tests |  | 3d? | 2005-08-23 | 2005-08-25 | 10 | 5d | 0d | ME | 24h |
| 12 | 1.1.7 | LP-VB ready | milestone | 0d | 2005-08-25 | 2005-08-25 | 11 | 5d |  |  |  |
| 13 | 1.2 | **Demo MinContSpeed** |  | 23d? | 2005-08-01 | 2005-08-31 |  | 0d |  |  | 192h |
| 14 | 1.2.1 | **Software** |  | 23d? | 2005-08-01 | 2005-08-31 |  | 0d |  |  | 192h |
| 15 | 1.2.1.1 | Refine pitch/altitude controllers for slow speed flight |  | 18d? | 2005-08-01 | 2005-08-24 |  | 0d |  | SE | 144h |
| 16 | 1.2.1.2 | Develop LP-VB controller code and integrate into MVC |  | 4d? | 2005-08-25 | 2005-08-30 | 15 | 0d |  | SE | 32h |
| 17 | 1.2.1.3 | Test altitude code during existing CTD runs |  | 1d? | 2005-08-31 | 2005-08-31 | 16 | 0d |  | SE; ME | 16h |
| 18 | 1.3 | **Test on BTS** |  | 24d? | 2005-08-01 | 2005-09-01 |  | 0d |  |  | 128h |
| 19 | 1.3.1 | **Software** |  | 5d? | 2005-08-01 | 2005-08-05 |  | 19d |  |  | 40h |
| 20 | 1.3.1.1 | Write camera firing code and drivers |  | 2d? | 2005-08-01 | 2005-08-02 |  | 16d |  | SE | 16h |
| 21 | 1.3.1.2 | test fire on cameras |  | 1d? | 2005-08-03 | 2005-08-03 | 20 | 19d | 0d | SE | 8h |
| 22 | 1.3.1.3 | final controller code modifications |  | 2d? | 2005-08-04 | 2005-08-05 | 21 | 19d |  | SE | 16h |
| 23 | 1.3.2 | **Mechanical** |  | 9d? | 2005-08-01 | 2005-08-11 |  | 14d |  |  | 72h |
| 24 | 1.3.2.1 | Design camera and strobe mounts |  | 4d? | 2005-08-01 | 2005-08-04 |  | 14d | 0d | ME | 32h |
| 25 | 1.3.2.2 | fabricate brackets |  | 1d? | 2005-08-05 | 2005-08-05 | 24 | 14d | 0d | MS | 8h |
| 26 | 1.3.2.3 | mount camera and strobe |  | 3d? | 2005-08-08 | 2005-08-10 | 25 | 14d | 0d | MT | 24h |
| 27 | 1.3.2.4 | wire up and test |  | 1d? | 2005-08-11 | 2005-08-11 | 26 | 14d |  | ET | 8h |
| 28 | 1.3.3 | Deploy offshore and test |  | 1d? | 2005-09-01 | 2005-09-01 | 27, 17 | 0d |  | ME; SE | 16h |
