# DLSCAP 2007 Work Plan

Schedule from MS Project, 2006-09-01 to 2007-06-07.
MBARI

## Calendars

- Standard: Mon-Fri 08:00-12:00, 13:00-17:00; Sat-Sun off.

## Resources

| Resource |
| --- |
| Lance |
| Brett |
| Thomas |
| Machine shop |
| Jon |
| Lance McBride |
| Thomas Hoover |
| Test Tank |
| Rob Mcewen |
| Zephyr |
| Brett Hobson |
| Jon Erickson |
| AUV Fabricator #1 |
| Mike Godin |
| Yanwu Zhang |
| Rich |
| EE |
| SE |
| ME |
| MS |
| RE |
| ET |
| MT |
| SE ME |

## Schedule

| ID | WBS | Task | Duration | Start | Finish | Predecessors | Total slack | Free slack | Constraint | Resources | Work |
| --- | --- | --- | --- | --- | --- | --- | --- | --- | --- | --- | --- |
| 1 | 1 | **Dorado LS** | 200d | 2006-09-01 | 2007-06-07 |  | 0d |  |  |  | 2916.8h |
| 2 | 1.1 | **2006 Work Plan** | 28.33d | 2006-09-01 | 2006-10-11 |  | 171.67d |  |  |  | 136h |
| 3 | 1.1.1 | Define and defend Functional Requirements | 5d | 2006-09-01 | 2006-09-07 |  | 171.67d | 0d |  | ME [20%]; SE [20%]; EE [20%] | 24h |
| 4 | 1.1.2 | Define camera requirements | 5d | 2006-09-08 | 2006-09-14 | 3 | 171.67d | 0d |  | ME [20%]; SE [20%]; EE [20%] | 24h |
| 5 | 1.1.3 | Define sonar requirements | 5d | 2006-09-15 | 2006-09-21 | 4 | 171.67d | 0d |  | ME [20%]; SE [20%]; EE [20%] | 24h |
| 6 | 1.1.4 | Survey COTS sonars, cameras, lights, ballast tanks | 8.33d | 2006-09-22 | 2006-10-04 | 5 | 171.67d | 0d |  | ME [20%]; SE [20%]; EE [20%] | 40h |
| 7 | 1.1.5 | Refine Work plan | 5d | 2006-10-04 | 2006-10-11 | 6 | 171.67d |  |  | ME [20%]; SE [20%]; EE [20%] | 24h |
| 8 | 1.2 | **DLSCAP 2007 Work Plan** | 200d | 2006-09-01 | 2007-06-07 |  | 0d |  | start no earlier than 2006-09-01 |  | 2780.8h |
| 9 | 1.2.1 | **Obstacle Avoidance** | 101.67d | 2007-01-01 | 2007-05-22 |  | 0d |  |  |  | 592h |
| 10 | 1.2.1.1 | Select a sonar | 4d | 2007-01-01 | 2007-01-04 |  | 0d |  | must start on 2007-01-01 | ME [50%] | 16h |
| 11 | 1.2.1.2 | Design sonar mounts | 8d | 2007-01-05 | 2007-01-16 | 10 | 0d |  |  | ME [50%] | 32h |
| 12 | 1.2.1.3 | Design electrical integration | 10d | 2007-01-17 | 2007-01-30 | 11 | 12.33d | 0d |  | EE [50%] | 40h |
| 13 | 1.2.1.4 | Define control scheme | 6.67d | 2007-01-31 | 2007-02-08 | 12 | 12.33d | 0d |  | SE [75%] | 40h |
| 14 | 1.2.1.5 | PDR | 1.67d | 2007-02-08 | 2007-02-12 | 13 | 12.33d | 0d |  | ME; SE; EE | 40h |
| 15 | 1.2.1.6 | finish machine prints for mounts | 2d | 2007-02-12 | 2007-02-14 | 14 | 12.33d | 0d |  | ME [50%] | 8h |
| 16 | 1.2.1.7 | finish electrical schematics | 4d | 2007-02-14 | 2007-02-20 | 15 | 12.33d | 0d |  | EE [50%] | 16h |
| 17 | 1.2.1.8 | CDR | 1.33d | 2007-02-20 | 2007-02-21 | 16 | 12.33d | 0d |  | ME; SE; EE | 32h |
| 18 | 1.2.1.9 | order sonar | 2d | 2007-02-21 | 2007-02-23 | 17 | 12.33d | 0d |  | ME [50%] | 8h |
| 19 | 1.2.1.10 | order machine parts | 2d | 2007-02-23 | 2007-02-27 | 18 | 12.33d | 0d |  | MS | 16h |
| 20 | 1.2.1.11 | order connectors and wet cabling | 2d | 2007-02-27 | 2007-03-01 | 19 | 12.33d | 0d |  | EE [50%] | 8h |
| 21 | 1.2.1.12 | write sonar driver | 9.33d | 2007-03-01 | 2007-03-14 | 20 | 12.33d | 0d |  | SE [75%] | 56h |
| 22 | 1.2.1.13 | develop bottom tracking | 14.67d | 2007-03-15 | 2007-04-04 | 21 | 12.33d | 0d |  | SE [75%] | 88h |
| 23 | 1.2.1.14 | develop obstical tracking | 6.67d | 2007-04-04 | 2007-04-13 | 22 | 12.33d | 0d |  | SE [75%] | 40h |
| 24 | 1.2.1.15 | assemble sonar assembly | 4d | 2007-04-13 | 2007-04-19 | 23 | 12.33d | 0d |  | SE [75%] | 24h |
| 25 | 1.2.1.16 | wire up and test | 4d | 2007-04-19 | 2007-04-25 | 24 | 12.33d | 0d |  | SE [75%] | 24h |
| 26 | 1.2.1.17 | test controllers | 9.33d | 2007-04-25 | 2007-05-08 | 25 | 12.33d | 0d |  | SE [75%] | 56h |
| 27 | 1.2.1.18 | conduct pool testing | 10d | 2007-05-08 | 2007-05-22 | 26 | 12.33d |  |  | ME [20%]; SE [20%]; EE [20%] | 48h |

| ID | WBS | Task | Duration | Start | Finish | Predecessors | Total slack | Free slack | Resources | Work |
| --- | --- | --- | --- | --- | --- | --- | --- | --- | --- | --- |
| 28 | 1.2.2 | **Imaging system** | 73.67d | 2007-01-17 | 2007-04-30 |  | 0d |  |  | 420.8h |
| 29 | 1.2.2.1 | camera design | 4d | 2007-01-17 | 2007-01-22 | 11 | 0d |  | ME [50%] | 16h |
| 30 | 1.2.2.2 | lighting design | 2d | 2007-01-23 | 2007-01-24 | 29 | 0d |  | ME; EE | 32h |
| 31 | 1.2.2.3 | Design mounts | 10d | 2007-01-25 | 2007-02-07 | 30 | 0d |  | ME [50%] | 40h |
| 32 | 1.2.2.4 | Design camera control system | 6.67d | 2007-02-08 | 2007-02-16 | 31 | 7.33d | 0d | SE [75%] | 40h |
| 33 | 1.2.2.5 | PDR | 3d | 2007-02-16 | 2007-02-21 | 32 | 7.33d | 0d | ME [20%]; SE [20%]; EE [20%] | 14.4h |
| 34 | 1.2.2.6 | Finish prints for mechanical mounts, | 4d | 2007-02-21 | 2007-02-27 | 33 | 7.33d | 0d | ME [50%] | 16h |
| 35 | 1.2.2.7 | Finish electrical schematics | 2d | 2007-02-27 | 2007-03-01 | 34 | 7.33d | 0d | EE [50%] | 8h |
| 36 | 1.2.2.8 | Finish camera controller design | 4d | 2007-03-01 | 2007-03-07 | 35 | 7.33d | 0d | SE [75%] | 24h |
| 37 | 1.2.2.9 | CDR | 3d | 2007-03-07 | 2007-03-12 | 36 | 7.33d | 0d | ME [20%]; SE [20%]; EE [20%] | 14.4h |
| 38 | 1.2.2.10 | Order camera | 2d | 2007-03-12 | 2007-03-14 | 37 | 7.33d | 0d | ME [50%] | 8h |
| 39 | 1.2.2.11 | Order stobes | 2d | 2007-03-14 | 2007-03-16 | 38 | 7.33d | 0d | ME [50%] | 8h |
| 40 | 1.2.2.12 | connectros and wet cabling | 2d | 2007-03-16 | 2007-03-20 | 39 | 7.33d | 0d | EE [50%] | 8h |
| 41 | 1.2.2.13 | Write camera driver | 4d | 2007-03-20 | 2007-03-26 | 40 | 7.33d | 0d | SE [75%] | 24h |
| 42 | 1.2.2.14 | Machine parts | 13d | 2007-03-26 | 2007-04-12 | 41 | 19.33d | 0d | MS | 104h |
| 43 | 1.2.2.15 | Install camera | 4d | 2007-04-12 | 2007-04-18 | 42 | 19.33d | 0d | ME [50%] | 16h |
| 44 | 1.2.2.16 | Install strobes | 3d | 2007-04-18 | 2007-04-23 | 43 | 19.33d | 0d | ME | 24h |
| 45 | 1.2.2.17 | Test in tank | 5d | 2007-04-23 | 2007-04-30 | 44 | 19.33d |  | ME [20%]; SE [20%]; EE [20%] | 24h |
| 46 | 1.2.3 | **LP-VB system** | 77d | 2007-02-08 | 2007-05-25 |  | 0d |  |  | 544h |
| 47 | 1.2.3.1 | **Mechanical** | 28d | 2007-02-08 | 2007-03-19 |  | 0d |  |  | 152h |
| 48 | 1.2.3.1.1 | layout | 10d | 2007-02-08 | 2007-02-21 | 31 | 0d |  | ME [50%] | 40h |
| 49 | 1.2.3.1.2 | component spec | 2d | 2007-02-22 | 2007-02-23 | 48 | 0d |  | ME [50%] | 8h |
| 50 | 1.2.3.1.3 | PDR | 2d | 2007-02-26 | 2007-02-27 | 49 | 0d |  | ME [50%] | 8h |
| 51 | 1.2.3.1.4 | refine system | 2d | 2007-02-28 | 2007-03-01 | 50 | 0d |  | ME [50%] | 8h |
| 52 | 1.2.3.1.5 | CDR | 2d | 2007-03-02 | 2007-03-05 | 51 | 0d |  | ME [50%] | 8h |
| 53 | 1.2.3.1.6 | machine parts | 10d | 2007-03-06 | 2007-03-19 | 52 | 0d |  | MS | 80h |
| 54 | 1.2.3.2 | assemble and test | 2d | 2007-03-20 | 2007-03-21 | 53 | 0d |  | ME [50%] | 8h |
| 55 | 1.2.3.3 | install and test in tank | 4d | 2007-03-22 | 2007-03-27 | 54 | 0d |  | ME [50%] | 16h |
| 56 | 1.2.3.4 | rework | 2d | 2007-03-28 | 2007-03-29 | 55 | 0d |  | ME [50%] | 8h |

| ID | WBS | Task | Duration | Start | Finish | Predecessors | Total slack | Free slack | Resources | Work |
| --- | --- | --- | --- | --- | --- | --- | --- | --- | --- | --- |
| 57 | 1.2.3.5 | **Electrical** | 36d | 2007-03-30 | 2007-05-18 | 56 | 0d |  |  | 144h |
| 58 | 1.2.3.5.1 | Specify Microcontroller | 8d | 2007-03-30 | 2007-04-10 |  | 0d |  | EE [50%] | 32h |
| 59 | 1.2.3.5.2 | Design circuit | 10d | 2007-04-11 | 2007-04-24 | 58 | 0d |  | EE [50%] | 40h |
| 60 | 1.2.3.5.3 | PDR | 2d | 2007-04-25 | 2007-04-26 | 59 | 0d |  | EE [50%] | 8h |
| 61 | 1.2.3.5.4 | refine system | 6d | 2007-04-27 | 2007-05-04 | 60 | 0d |  | EE [50%] | 24h |
| 62 | 1.2.3.5.5 | CDR | 2d | 2007-05-07 | 2007-05-08 | 61 | 0d |  | EE [50%] | 8h |
| 63 | 1.2.3.5.6 | build and test | 8d | 2007-05-09 | 2007-05-18 | 62 | 0d |  | EE [50%] | 32h |
| 64 | 1.2.3.6 | **Software** | 32d | 2007-03-26 | 2007-05-09 |  | 7.33d |  |  | 192h |
| 65 | 1.2.3.6.1 | define software | 6.67d | 2007-03-26 | 2007-04-04 | 41 | 7.33d | 0d | SE [75%] | 40h |
| 66 | 1.2.3.6.2 | PDR | 1.33d | 2007-04-04 | 2007-04-05 | 65 | 7.33d | 0d | SE [75%] | 8h |
| 67 | 1.2.3.6.3 | refine system | 2.67d | 2007-04-05 | 2007-04-10 | 66 | 7.33d | 0d | SE [75%] | 16h |
| 68 | 1.2.3.6.4 | CDR | 1.33d | 2007-04-10 | 2007-04-11 | 67 | 7.33d | 0d | SE [75%] | 8h |
| 69 | 1.2.3.6.5 | write driver | 6.67d | 2007-04-11 | 2007-04-20 | 68 | 7.33d | 0d | SE [75%] | 40h |
| 70 | 1.2.3.6.6 | modify abort behavior | 2.67d | 2007-04-20 | 2007-04-24 | 69 | 7.33d | 0d | SE [75%] | 16h |
| 71 | 1.2.3.6.7 | multi variable controller | 10.67d | 2007-04-25 | 2007-05-09 | 70 | 7.33d |  | SE [75%] | 64h |
| 72 | 1.2.3.7 | tank testing | 5d | 2007-05-21 | 2007-05-25 | 71, 63, 56 | 0d |  | ME [20%]; SE [20%]; EE [20%] | 24h |
| 73 | 1.2.4 | **Test offshore** | 200d | 2006-09-01 | 2007-06-07 |  | 0d |  | ME [20%]; SE [20%]; EE [20%] | 1224h |
| 74 | 1.2.4.1 | Tow-out tests | 5d | 2007-05-28 | 2007-06-01 | 72, 45 | 0d |  | ME; SE; EE | 120h |
| 75 | 1.2.4.2 | Zephyr tests 1 | 2d | 2007-06-04 | 2007-06-05 | 74 | 0d |  | ME; SE; EE | 48h |
| 76 | 1.2.4.3 | Zephyr tests 2 | 2d | 2007-06-06 | 2007-06-07 | 75 | 0d |  | ME; SE; EE | 48h |
| 77 | 1.2.4.4 | Zephyr tests 3 | 2d | 2006-09-01 | 2006-09-04 |  | 198d |  | ME; SE; EE | 48h |
